# Configuration and Customisation Phase Gantt Chart

Schedule from MS Project, 2009-02-01 to 2009-06-01.
Project Perfect

## Calendars

- Standard: Mon-Fri 08:00-12:00, 13:00-17:00; Sat-Sun off.

## Schedule

| ID | WBS | Task | Type | Duration | Start | Finish | Predecessors | Total slack | Free slack |
| --- | --- | --- | --- | --- | --- | --- | --- | --- | --- |
| 1 | 1 | NOTE: All time estimates are duration rather than work. They will have to be scaled up or down to suit the project. | milestone | 0d | 2009-02-01 | 2009-02-01 |  | 20.6d |  |
| 4 | 2 | **Phase Planning** |  | 2.3d | 2009-02-02 | 2009-02-04 |  | 0d |  |
| 5 | 2.1 | Review the draft plan and look for changes |  | 0.2d | 2009-02-02 | 2009-02-02 |  | 0d |  |
| 6 | 2.2 | Prepare a schedule (Gantt Chart) |  | 0.2d | 2009-02-02 | 2009-02-02 | 5 | 0d |  |
| 7 | 2.3 | Allocate resources |  | 0.2d | 2009-02-02 | 2009-02-02 | 6 | 0d |  |
| 8 | 2.4 | Confirm resource availability |  | 0.5d | 2009-02-02 | 2009-02-03 | 7 | 0d |  |
| 9 | 2.5 | Revise list of issues and risks |  | 0.2d | 2009-02-03 | 2009-02-03 | 8 | 0d |  |
| 10 | 2.6 | Gain agreement to proceed |  | 1d | 2009-02-03 | 2009-02-04 | 9 | 0d |  |
| 11 | 2.7 | Planning complete | milestone | 0d | 2009-02-04 | 2009-02-04 | 10 | 0d |  |
| 12 | 3 | **Kick Off Meeting** |  | 2.5d | 2009-02-02 | 2009-02-04 |  | 0d |  |
| 13 | 3.1 | Schedule meeting |  | 2d | 2009-02-02 | 2009-02-03 |  | 0.3d |  |
| 14 | 3.2 | Prepare material |  | 1d | 2009-02-02 | 2009-02-02 |  | 1d |  |
| 15 | 3.3 | Hold meeting |  | 0.2d | 2009-02-04 | 2009-02-04 | 13, 14, 11 | 0d |  |
| 16 | 3.4 | Kick Off meeting complete | milestone | 0d | 2009-02-04 | 2009-02-04 | 15 | 0d |  |
| 17 | 4 | **Environment** |  | 5d | 2009-02-04 | 2009-02-11 | 16 | 77.9d |  |
| 18 | 4.1 | Install esential infrastructure |  | 5d | 2009-02-04 | 2009-02-11 |  | 77.9d | 0d |
| 19 | 4.2 | Install software |  | 5d | 2009-02-04 | 2009-02-11 |  | 77.9d | 0d |
| 20 | 4.3 | Environment created | milestone | 0d | 2009-02-11 | 2009-02-11 | 18, 19 | 77.9d |  |
| 21 | 5 | **Data** |  | 35d | 2009-02-04 | 2009-03-25 | 16 | 47.9d |  |
| 22 | 5.1 | Identify data conversion requirements |  | 5d | 2009-02-04 | 2009-02-11 |  | 47.9d | 0d |
| 23 | 5.2 | Prepare data |  | 30d | 2009-02-11 | 2009-03-25 | 22 | 47.9d | 0d |
| 24 | 5.3 | Data ready for trial | milestone | 0d | 2009-03-25 | 2009-03-25 | 23 | 47.9d |  |
| 25 | 6 | **Configuration** |  | 38d | 2009-02-04 | 2009-03-30 | 16 | 18d |  |
| 26 | 6.1 | Identify configuration requirements |  | 5d | 2009-02-04 | 2009-02-11 |  | 18d | 0d |
| 27 | 6.2 | Schedule configuration |  | 3d | 2009-02-11 | 2009-02-16 | 26 | 18d | 0d |
| 28 | 6.3 | Carry out configuration |  | 30d | 2009-02-16 | 2009-03-30 | 27 | 18d | 0d |
| 29 | 6.4 | Configuration complete | milestone | 0d | 2009-03-30 | 2009-03-30 | 28 | 18d |  |

| ID | WBS | Task | Type | Duration | Start | Finish | Predecessors | Total slack | Free slack |
| --- | --- | --- | --- | --- | --- | --- | --- | --- | --- |
| 30 | 7 | **Customisation** |  | 35d | 2009-02-04 | 2009-03-25 | 16 | 0d |  |
| 31 | 7.1 | Identify customisation requirements |  | 3d | 2009-02-04 | 2009-02-09 |  | 0d |  |
| 32 | 7.2 | Schedule customisation |  | 2d | 2009-02-09 | 2009-02-11 | 31 | 0d |  |
| 33 | 7.3 | Carry out customisation |  | 30d | 2009-02-11 | 2009-03-25 | 32 | 0d |  |
| 34 | 7.4 | Customisation complete | milestone | 0d | 2009-03-25 | 2009-03-25 | 33 | 0d |  |
| 35 | 8 | **Trial Conversion** |  | 21d | 2009-03-25 | 2009-04-23 | 34 | 0d |  |
| 36 | 8.1 | Carry out trial conversion |  | 3d | 2009-03-25 | 2009-03-30 |  | 0d |  |
| 37 | 8.2 | Carry out testing |  | 5d | 2009-03-30 | 2009-04-06 | 36 | 0d |  |
| 38 | 8.3 | Carry out rework on conversion programs and data |  | 10d | 2009-04-06 | 2009-04-20 | 37 | 0d |  |
| 39 | 8.4 | Carry out second trial conversion |  | 3d | 2009-04-20 | 2009-04-23 | 38 | 0d |  |
| 40 | 8.5 | Trial complete | milestone | 0d | 2009-04-23 | 2009-04-23 | 39 | 0d |  |
| 41 | 9 | **User Acceptance Testing** |  | 78.5d | 2009-02-02 | 2009-05-21 |  | 0d |  |
| 42 | 9.1 | Prepare test strategy |  | 5d | 2009-02-02 | 2009-02-06 |  | 25d | 0d |
| 43 | 9.2 | Carry out QA on test strategy |  | 1d | 2009-02-09 | 2009-02-09 | 42 | 25d | 0d |
| 44 | 9.3 | Carry out rework on test strategy |  | 0.5d | 2009-02-10 | 2009-02-10 | 43 | 25d | 0d |
| 45 | 9.4 | Agree test strategy |  | 2d | 2009-02-10 | 2009-02-12 | 44 | 25d | 0d |
| 46 | 9.5 | Test strategy agreed | milestone | 0d | 2009-02-12 | 2009-02-12 | 45 | 25d | 0d |
| 47 | 9.6 | Prepare test plan(scenarios and scripts) |  | 20d | 2009-02-12 | 2009-03-12 | 46 | 25d | 0d |
| 48 | 9.7 | Carry out QA on test plan |  | 2d | 2009-03-12 | 2009-03-16 | 47 | 25d | 0d |
| 49 | 9.8 | Carry out rework |  | 3d | 2009-03-16 | 2009-03-19 | 48 | 25d | 0d |
| 50 | 9.9 | Test plan complete | milestone | 0d | 2009-03-19 | 2009-03-19 | 49 | 25d |  |
| 51 | 9.10 | Carry out UAT |  | 15d | 2009-04-23 | 2009-05-14 | 50, 40, 29, 34 | 0d |  |
| 52 | 9.11 | Carry out rework from UAT |  | 20d | 2009-04-23 | 2009-05-21 | 51SS | 0d |  |
| 53 | 9.12 | UAT signed off | milestone | 0d | 2009-05-21 | 2009-05-21 | 52 | 0d |  |

Notes:
- 35: May be several iterations of this conversion task

| ID | WBS | Task | Type | Duration | Start | Finish | Predecessors | Total slack |
| --- | --- | --- | --- | --- | --- | --- | --- | --- |
| 54 | 10 | **Implementation activity list** |  | 1d | 2009-05-21 | 2009-05-22 | 53 | 0d |
| 55 | 10.1 | Update implementation activity list |  | 1d | 2009-05-21 | 2009-05-22 |  | 0d |
| 56 | 10.2 | Implementation activity list up to date | milestone | 0d | 2009-05-22 | 2009-05-22 | 55 | 0d |
| 57 | 11 | **Report** |  | 4d | 2009-05-22 | 2009-05-28 | 56 | 0d |
| 58 | 11.1 | Produce report |  | 2d | 2009-05-22 | 2009-05-26 |  | 0d |
| 59 | 11.2 | Carry out QA |  | 0.5d | 2009-05-26 | 2009-05-26 | 58 | 0d |
| 60 | 11.3 | Carry out rework |  | 1d | 2009-05-27 | 2009-05-27 | 59 | 0d |
| 61 | 11.4 | Present report |  | 0.5d | 2009-05-28 | 2009-05-28 | 60 | 0d |
| 62 | 11.5 | Report complete | milestone | 0d | 2009-05-28 | 2009-05-28 | 61 | 0d |
| 63 | 12 | **Closure** |  | 1.9d | 2009-05-28 | 2009-06-01 | 62 | 0d |
| 64 | 12.1 | Produce plan for next phase |  | 0.4d | 2009-05-28 | 2009-05-28 |  | 0d |
| 65 | 12.2 | Agree plan with the Sponsor |  | 1d | 2009-05-28 | 2009-05-29 | 64 | 0d |
| 66 | 12.3 | Agree to proceed through the gate to the next phase |  | 0.5d | 2009-05-29 | 2009-06-01 | 65 | 0d |
| 67 | 12.4 | Phase complete | milestone | 0d | 2009-06-01 | 2009-06-01 | 66 | 0d |
